# План выполнения работ, ред. 01

Schedule from MS Project, 2011-06-06 to 2011-09-26, costs in р..
***

## Calendars

- Стандартный: Mon-Fri 09:00-13:00, 14:00-18:00; Sat-Sun off.

## Resources

| Resource | Rate |
| --- | --- |
| Руководитель проекта | 400 |
| Постановщик задач исполнителя 2 | 300 |
| Разработчик системы 1 | 350 |
| Разработчик системы 2 | 350 |
| Разработчик системы 3 | 350 |
| Архитектор системы | 350 |
| Постановщик задач исполнителя 1 | 150 |
| Технический специалист | 300 |
| Специалист по внедрению | 200 |
| Разработчик документации | 250 |
| Архитектор системы, |  |

## Schedule

| ID | WBS | Task | Duration | Start | Finish | Predecessors | Total slack | Free slack | Constraint | Resources | Work | Cost |
| --- | --- | --- | --- | --- | --- | --- | --- | --- | --- | --- | --- | --- |
| 1 | 1 | **Разработка автоматизированной информационной системы «Балтик-Лайт»** | 81d | 2011-06-06 | 2011-09-26 |  | 0d |  |  |  | 1368h | 372,000 |
| 2 | 1.1 | **Этап 1. Запуск подсистемы "Прием, обработка и согласование заявок от клиентов, расчет себестоимости"** | 18d | 2011-06-06 | 2011-06-29 |  | 0d |  |  |  | 448h | 126,080 |
| 3 | 1.1.1 | Формирование необходимых структур и словарей для БД | 4d | 2011-06-06 | 2011-06-09 |  | 0d |  | start no earlier than 2011-06-06 | Архитектор системы; Постановщик задач исполнителя 1 | 64h | 16,000 |
| 4 | 1.1.2 | Миграция и актуализация данных по подсистеме "Прием, обработка и согласование заявок от клиентов, расчет себестоимости" | 4d | 2011-06-10 | 2011-06-15 | 3 | 71d | 0d |  | Постановщик задач исполнителя 1; Технический специалист | 64h | 14,400 |
| 5 | 1.1.3 | Разработка необходимых бланков печатных форм в части подсистемы "Прием, обработка и согласование заявок от клиентов, расчет себестоимости" | 2d | 2011-06-16 | 2011-06-17 | 4 | 71d |  |  | Специалист по внедрению | 16h | 3,200 |
| 6 | 1.1.4 | **Разработка требуемой функциональности для подсистемы "Прием, обработка и согласование заявок от клиентов, расчет себестоимости", в т.ч.:** | 12d | 2011-06-10 | 2011-06-27 |  | 0d |  |  | Архитектор системы [20%]; Постановщик задач исполнителя 1 [30%]; Разработчик системы 1 | 288h | 89,280 |
| 7 | 1.1.4.1 | 1.1. Функциональность бизнес-процесса первичного приема Заявок от клиентов, пп 2.1 ТЗ | 3d | 2011-06-10 | 2011-06-14 | 3 | 0d |  |  | Архитектор системы [20%]; Постановщик задач исполнителя 1 [30%]; Разработчик системы 1 | 36h | 11,160 |
| 8 | 1.1.4.2 | 1.2. Функциональность учета клиентов – юридических и физических лиц, пп 2.2 ТЗ | 1d | 2011-06-15 | 2011-06-15 | 7 | 0d |  |  | Архитектор системы [20%]; Постановщик задач исполнителя 1 [30%]; Разработчик системы 1 | 12h | 3,720 |
| 9 | 1.1.4.3 | 1.3. Функциональность бизнес-процесса технологической обработки заявок, формирования типовых договоров и ТЗ к ним, алгоритмы расчета себестоимости, пп 2.3 ТЗ | 5d | 2011-06-16 | 2011-06-22 | 8 | 0d |  |  | Архитектор системы [20%]; Постановщик задач исполнителя 1 [30%]; Разработчик системы 1 | 60h | 18,600 |
| 10 | 1.1.4.4 | 1.4. Функциональность бизнес-процессов организации системы календарного планирования, напоминаний, формирования и контроля исполнения задач и поручений, пп 2.9 ТЗ | 3d | 2011-06-23 | 2011-06-27 | 9 | 0d |  |  | Архитектор системы [20%]; Постановщик задач исполнителя 1 [30%]; Разработчик системы 1 | 36h | 11,160 |
| 11 | 1.1.5 | Тестовая эксплуатация системы в части подсистемы "Прием, обработка и согласование заявок от клиентов, расчет себестоимости" | 2d | 2011-06-28 | 2011-06-29 | 10 | 0d |  |  | Специалист по внедрению | 16h | 3,200 |
| 12 | 1.2 | **Этап 2. Запуск подсистемы "Закупка сырья и материалов"** | 10d | 2011-06-30 | 2011-07-13 |  | 0d |  |  |  | 108h | 27,160 |
| 13 | 1.2.1 | Формирование необходимых структур, классификаторов и словарей для БД | 2d | 2011-06-30 | 2011-07-01 | 11 | 0d |  | start no earlier than 2011-06-06 | Архитектор системы; Постановщик задач исполнителя 1 | 32h | 8,000 |
| 14 | 1.2.2 | Разработка необходимых бланков печатных форм в части подсистемы "Закупка сырья и материалов" | 3d | 2011-07-04 | 2011-07-06 | 13 | 0d |  |  | Специалист по внедрению | 24h | 4,800 |
| 15 | 1.2.3 | Разработка требуемой функциональности для подсистемы "Закупка сырья и материалов", пп 2.4 ТЗ | 3d | 2011-07-07 | 2011-07-11 | 14 | 0d |  |  | Архитектор системы [20%]; Постановщик задач исполнителя 1 [30%]; Разработчик системы 1 | 36h | 11,160 |
| 16 | 1.2.4 | Тестовая эксплуатация системы в части подсистемы "Закупка сырья и материалов" | 2d | 2011-07-12 | 2011-07-13 | 15 | 0d |  |  | Специалист по внедрению | 16h | 3,200 |
| 17 | 1.3 | **Этап 3. Запуск подсистемы "Производство готовой продукции"** | 12d | 2011-07-14 | 2011-07-29 |  | 0d |  |  |  | 140h | 37,000 |
| 18 | 1.3.1 | Формирование необходимых структур, классификаторов и словарей для БД | 3d | 2011-07-14 | 2011-07-18 | 16 | 0d |  | start no earlier than 2011-06-06 | Архитектор системы; Постановщик задач исполнителя 1 | 48h | 12,000 |
| 19 | 1.3.2 | Разработка необходимых бланков печатных форм в части подсистемы "Производство готовой продукции" | 2d | 2011-07-19 | 2011-07-20 | 18 | 0d |  |  | Специалист по внедрению | 16h | 3,200 |
| 20 | 1.3.3 | Разработка требуемой функциональности для подсистемы "Производство готовой продукции", пп 2.5 ТЗ | 5d | 2011-07-21 | 2011-07-27 | 19 | 0d |  |  | Архитектор системы [20%]; Постановщик задач исполнителя 1 [30%]; Разработчик системы 1 | 60h | 18,600 |
| 21 | 1.3.4 | Тестовая эксплуатация системы в части подсистемы "Производство готовой продукции" | 2d | 2011-07-28 | 2011-07-29 | 20 | 0d |  |  | Специалист по внедрению | 16h | 3,200 |
| 22 | 1.4 | **Этап 4. Запуск подсистемы "Организация и учет взаиморасчетов с клиентами, поставщиками и субподрядными организациями"** | 20d | 2011-08-01 | 2011-08-26 |  | 0d |  |  |  | 232h | 62,800 |
| 23 | 1.4.1 | Формирование необходимых структур, классификаторов и словарей для БД | 4d | 2011-08-01 | 2011-08-04 | 21 | 0d |  | start no earlier than 2011-06-06 | Архитектор системы; Постановщик задач исполнителя 1 | 64h | 16,000 |
| 24 | 1.4.2 | Разработка необходимых бланков печатных форм в части подсистемы "Организация и учет взаиморасчетов с клиентами, поставщиками и субподрядными организациями" | 4d | 2011-08-05 | 2011-08-10 | 23 | 0d |  |  | Специалист по внедрению | 32h | 6,400 |
| 25 | 1.4.3 | Разработка требуемой функциональности для подсистемы "Организация и учет взаиморасчетов с клиентами, поставщиками и субподрядными организациями", пп 2.8 ТЗ | 10d | 2011-08-11 | 2011-08-24 | 24 | 0d |  |  | Архитектор системы [20%]; Постановщик задач исполнителя 1 [30%]; Разработчик системы 1 | 120h | 37,200 |
| 26 | 1.4.4 | Тестовая эксплуатация системы в части подсистемы "Организация и учет взаиморасчетов с клиентами, поставщиками и субподрядными организациями" | 2d | 2011-08-25 | 2011-08-26 | 25 | 0d |  |  | Специалист по внедрению | 16h | 3,200 |

| ID | WBS | Task | Duration | Start | Finish | Predecessors | Total slack | Constraint | Resources | Work | Cost |
| --- | --- | --- | --- | --- | --- | --- | --- | --- | --- | --- | --- |
| 27 | 1.5 | **Этап 5. Запуск подсистемы "Обеспечение транспортной деятельности и монтажных работ"** | 9d | 2011-08-29 | 2011-09-08 |  | 0d |  |  | 152h | 42,560 |
| 28 | 1.5.1 | Формирование необходимых структур, классификаторов и словарей для БД | 2d | 2011-08-29 | 2011-08-30 | 26 | 0d | start no earlier than 2011-06-06 | Архитектор системы; Постановщик задач исполнителя 1 | 32h | 8,000 |
| 29 | 1.5.2 | Разработка необходимых бланков печатных форм в части подсистемы "Обеспечение транспортной деятельности и монтажных работ" | 1d | 2011-08-31 | 2011-08-31 | 28 | 0d |  | Специалист по внедрению | 8h | 1,600 |
| 30 | 1.5.3 | **Разработка требуемой функциональности для подсистемы "Обеспечение транспортной деятельности и монтажных работ"** | 4d | 2011-09-01 | 2011-09-06 | 29 | 0d |  | Архитектор системы [20%]; Постановщик задач исполнителя 1 [30%]; Разработчик системы 1 | 96h | 29,760 |
| 31 | 1.5.3.1 | 5.1. Функциональность бизнес-процесса обеспечения транспортной деятельности, пп 2.6 ТЗ | 3d | 2011-09-01 | 2011-09-05 |  | 0d |  | Архитектор системы [20%]; Постановщик задач исполнителя 1 [30%]; Разработчик системы 1 | 36h | 11,160 |
| 32 | 1.5.3.2 | 5.2. Функциональность бизнес-процесса учета выполнения монтажных работ, пп 2.7 ТЗ | 1d | 2011-09-06 | 2011-09-06 | 31 | 0d |  | Архитектор системы [20%]; Постановщик задач исполнителя 1 [30%]; Разработчик системы 1 | 12h | 3,720 |
| 33 | 1.5.4 | Тестовая эксплуатация системы в части подсистемы "Обеспечение транспортной деятельности и монтажных работ" | 2d | 2011-09-07 | 2011-09-08 | 32 | 0d |  | Специалист по внедрению | 16h | 3,200 |
| 34 | 1.6 | **Этап 6. Запуск подсистемы "Формирование аналитических расчетов"** | 12d | 2011-09-09 | 2011-09-26 |  | 0d |  |  | 136h | 38,560 |
| 35 | 1.6.1 | Формирование необходимых структур, классификаторов и словарей для БД | 1d | 2011-09-09 | 2011-09-09 | 33 | 0d | start no earlier than 2011-06-06 | Архитектор системы; Постановщик задач исполнителя 1 | 16h | 4,000 |
| 36 | 1.6.2 | Разработка требуемой функциональности для подсистемы "Формирование аналитических расчетов", пп 2.11 ТЗ | 8d | 2011-09-12 | 2011-09-21 | 35 | 0d |  | Архитектор системы [20%]; Постановщик задач исполнителя 1 [30%]; Разработчик системы 1 | 96h | 29,760 |
| 37 | 1.6.3 | Тестовая эксплуатация системы в части подсистемы "Формирование аналитических расчетов" | 3d | 2011-09-22 | 2011-09-26 | 36 | 0d |  | Специалист по внедрению | 24h | 4,800 |
| 38 | 1.7 | **Этап 7. Обучение и запуск Системы в целом в опытно-промышленную эксплуатацию** | 12d | 2011-09-09 | 2011-09-26 |  | 0d |  |  | 152h | 37,840 |
| 39 | 1.7.1 | Подготовка инструкций для всех ролей пользователей | 6d | 2011-09-09 | 2011-09-16 | 33 | 0d | start no earlier than 2011-06-06 | Архитектор системы; Постановщик задач исполнителя 1 | 96h | 24,000 |
| 40 | 1.7.2 | Настройка прав доступа и переходов по статусам для всех ролей пользователей | 2d | 2011-09-19 | 2011-09-20 | 39 | 0d |  | Архитектор системы [20%]; Постановщик задач исполнителя 1 [30%]; Разработчик системы 1 | 24h | 7,440 |
| 41 | 1.7.3 | Тестовая эксплуатация системы в целом и запуск в промышленную эксплуатацию | 4d | 2011-09-21 | 2011-09-26 | 40 | 0d |  | Специалист по внедрению | 32h | 6,400 |
